# Zmiana lokalizacji

Schedule from MS Project, 2003-04-01 to 2003-05-30.
Przeprowadzka firmy do nowej siedziby
ABC sp z o.o.

## Calendars

- Standardowy: Mon-Fri 09:00-13:00, 14:00-18:00; Sat-Sun off. Exceptions (off unless hours are given): 2003-04-21, 2003-05-01.

## Schedule

| ID | WBS | Task | Type | Duration | Start | Finish | Predecessors | Total slack | Free slack | Constraint | Deadline |
| --- | --- | --- | --- | --- | --- | --- | --- | --- | --- | --- | --- |
| 1 | przeprowadzka-** | Start | milestone | 0d | 2003-04-01 09:00 | 2003-04-01 09:00 |  | 3.5d | 0d |  |  |
| 2 | przeprowadzka-** | **Poszukiwanie lokalu** |  | 12.5d? | 2003-04-01 09:00 | 2003-04-17 13:00 |  | 0d |  |  |  |
| 3 | przeprowadzka-**-01 | Określenie potrzeb |  | 1d | 2003-04-01 09:00 | 2003-04-01 18:00 | 1 | 3.5d | 0d |  |  |
| 4 | przeprowadzka-**-02 | Przygotowanie ogłoszenia |  | 0.5d? | 2003-04-02 09:00 | 2003-04-02 13:00 | 3 | 3.5d | 0d | finish no later than 2003-04-07 18:00 |  |
| 5 | przeprowadzka-**-03 | Emisja ogłoszenia | milestone | 0d | 2003-04-10 09:00 | 2003-04-10 09:00 | 4 | 0d |  | must start on 2003-04-10 09:00 |  |
| 6 | przeprowadzka-**-04 | **Rozpatrywanie ofert** |  | 10.5d? | 2003-04-02 14:00 | 2003-04-16 18:00 |  | 0d |  |  |  |
| 7 | przeprowadzka-**-04-01 | **Ocena ofert** |  | 9.5d? | 2003-04-02 14:00 | 2003-04-15 18:00 |  | 0d |  |  |  |
| 8 | przeprowadzka-**-04-01-AA | Definiowanie kryteriów oceny |  | 0.5d | 2003-04-02 14:00 | 2003-04-02 18:00 | 4 | 5d |  |  |  |
| 9 | przeprowadzka-**-04-01-AB | Wpisywanie zgłoszonych ofert |  | 1d? | 2003-04-10 09:00 | 2003-04-10 18:00 | 5, 8 | 0d |  |  |  |
| 10 | przeprowadzka-**-04-01-AC | Wizyty w lokalach |  | 3d? | 2003-04-11 09:00 | 2003-04-15 18:00 | 9 | 0d |  |  |  |
| 11 | przeprowadzka-**-04-01-AD | Przypisywanie ocen |  | 1d | 2003-04-15 09:00 | 2003-04-15 18:00 | 10FF | 0d |  |  |  |
| 12 | przeprowadzka-**-04-02 | Spisanie i zebranie ocen |  | 1d | 2003-04-16 09:00 | 2003-04-16 18:00 | 11 | 0d |  |  | 2003-05-05 18:00 |
| 13 | przeprowadzka-**-05 | Wybór lokalu | milestone | 0d | 2003-04-16 18:00 | 2003-04-16 18:00 | 12 | 0d |  |  |  |
| 14 | przeprowadzka-**-06 | Wysyłanie powiadomień o decyzji |  | 0.5d | 2003-04-17 09:00 | 2003-04-17 13:00 | 13 | 0d |  |  |  |
| 15 | przeprowadzka-** | **Przygotowania do przeprowadzki** |  | 26d? | 2003-04-17 14:00 | 2003-05-27 13:00 |  | 0d |  |  |  |
| 16 | przeprowadzka-**-01 | Opiniowanie umowy |  | 2d | 2003-04-17 14:00 | 2003-04-22 13:00 | 14 | 0d |  |  |  |
| 17 | przeprowadzka-**-02 | Podpisanie umowy |  | 2h | 2003-04-22 14:00 | 2003-04-22 16:00 | 16 | 0d |  |  |  |
| 18 | przeprowadzka-**-03 | Wypowiedzenie umowy |  | 1h | 2003-04-22 12:00 | 2003-04-22 14:00 | 17SF | 26.81d |  |  |  |
| 19 | przeprowadzka-**-04 | Zdanie lokalu |  | 0.5d? | 2003-05-27 09:00 | 2003-05-27 13:00 | 26 | 2.81d |  |  |  |
| 20 | przeprowadzka-**-05 | Ustalenie terminu przeprowadzki |  | 0.5d? | 2003-04-22 16:00 | 2003-04-23 11:00 | 17 | 18.5d | 0d |  |  |
| 21 | przeprowadzka-**-06 | Aranżacja wnętrz |  | 1mo | 2003-04-22 16:00 | 2003-05-21 16:00 | 17 | 0d |  |  |  |
| 22 | przeprowadzka-** | **Przeprowadzka** |  | 26.06d | 2003-04-23 11:00 | 2003-05-30 11:30 |  | 0d |  |  |  |
| 23 | przeprowadzka-**-01 | Poszukiwanie środka transportu |  | 1d | 2003-04-23 11:00 | 2003-04-24 11:00 | 20 | 18.5d |  |  |  |
| 24 | przeprowadzka-**-02 | Odebranie lokalu |  | 1d | 2003-05-21 16:00 | 2003-05-22 16:00 | 21, 23 | 0d |  |  |  |
| 25 | przeprowadzka-**-03 | Pakowanie wyposażenia |  | 2d | 2003-05-22 16:00 | 2003-05-26 16:00 | 21, 24 | 0d |  |  |  |
| 26 | przeprowadzka-**-04 | Wynoszenie wyposażenia |  | 2h | 2003-05-26 16:00 | 2003-05-26 18:00 | 25 | 0d |  |  |  |
| 27 | przeprowadzka-**-05 | Załadunek |  | 1h | 2003-05-26 17:30 | 2003-05-27 09:30 | 26FS-2.5% | 0d |  |  |  |
| 28 | przeprowadzka-**-06 | Transport |  | 0.5h | 2003-05-27 09:30 | 2003-05-27 10:00 | 27 | 0d |  |  |  |
| 29 | przeprowadzka-**-07 | Wyładunek |  | 1h | 2003-05-27 10:00 | 2003-05-27 11:00 | 28 | 0d |  |  |  |
| 30 | przeprowadzka-**-08 | Wnoszenie wyposażenia |  | 2h | 2003-05-27 10:30 | 2003-05-27 12:30 | 29FS-5% | 0d |  |  |  |
| 31 | przeprowadzka-**-09 | Rozlokowanie sprzętu |  | 2d | 2003-05-27 11:00 | 2003-05-29 11:00 | 30FS-7.5% | 0.06d |  |  |  |
| 32 | przeprowadzka-**-10 | Rozlokowanie wyposażenia |  | 2d | 2003-05-27 11:30 | 2003-05-29 11:30 | 30FS-5% | 0d |  |  |  |
| 33 | przeprowadzka-**-11 | Sprzątanie |  | 1d | 2003-05-29 11:30 | 2003-05-30 11:30 | 31, 32 | 0d |  |  |  |
| 34 | przeprowadzka-** | Koniec | milestone | 0d | 2003-05-30 11:30 | 2003-05-30 11:30 | 19, 33 | 0d |  |  |  |

Notes:
- 3: Problematykę tą należy dodatkowo skonsultować z Janem Malinowskim i Krystyną Kowalską. Należy wziąć pod uwagę takie elementy jak: / ·wielkość powierzchni / ·podłączenie do internetu / ·klimatyzację

| ID | WBS | Task | Duration | Start | Finish | Total slack | Constraint |
| --- | --- | --- | --- | --- | --- | --- | --- |
| 35 | przeprowadzka-** | **Przygotowanie raportu** | 38.25d | 2003-04-04 09:00 | 2003-05-30 11:00 | 0.06d |  |
| 36 | przeprowadzka-**-01 | Przygotowanie raportu 1 | 2h | 2003-04-04 09:00 | 2003-04-04 11:00 | 38.06d | start no earlier than 2003-04-04 09:00 |
| 37 | przeprowadzka-**-02 | Przygotowanie raportu 2 | 2h | 2003-04-11 09:00 | 2003-04-11 11:00 | 33.06d | start no earlier than 2003-04-11 09:00 |
| 38 | przeprowadzka-**-03 | Przygotowanie raportu 3 | 2h | 2003-04-18 09:00 | 2003-04-18 11:00 | 28.06d | start no earlier than 2003-04-18 09:00 |
| 39 | przeprowadzka-**-04 | Przygotowanie raportu 4 | 2h | 2003-04-25 09:00 | 2003-04-25 11:00 | 24.06d | start no earlier than 2003-04-25 09:00 |
| 40 | przeprowadzka-**-05 | Przygotowanie raportu 5 | 2h | 2003-05-02 09:00 | 2003-05-02 11:00 | 20.06d | start no earlier than 2003-05-02 09:00 |
| 41 | przeprowadzka-**-06 | Przygotowanie raportu 6 | 2h | 2003-05-09 09:00 | 2003-05-09 11:00 | 15.06d | start no earlier than 2003-05-09 09:00 |
| 42 | przeprowadzka-**-07 | Przygotowanie raportu 7 | 2h | 2003-05-16 09:00 | 2003-05-16 11:00 | 10.06d | start no earlier than 2003-05-16 09:00 |
| 43 | przeprowadzka-**-08 | Przygotowanie raportu 8 | 2h | 2003-05-23 09:00 | 2003-05-23 11:00 | 5.06d | start no earlier than 2003-05-23 09:00 |
| 44 | przeprowadzka-**-09 | Przygotowanie raportu 9 | 2h | 2003-05-30 09:00 | 2003-05-30 11:00 | 0.06d | start no earlier than 2003-05-30 09:00 |
