# Zmiana lokalizacji

Schedule from MS Project, 2003-04-01 to 2003-05-30.
Przeprowadzka firmy do nowej siedziby
ABC sp z o.o.

## Calendars

- Standardowy: Mon-Fri 09:00-13:00, 14:00-18:00; Sat-Sun off. Exceptions (off unless hours are given): 2003-04-21, 2003-05-01.

## Resources

| Resource | Group | Unit | Rate | Cost per use |
| --- | --- | --- | --- | --- |
| Prezes | Administracja |  | 100 |  |
| Asystentka prezesa | Administracja |  | 20 |  |
| Grafik | Firma zewnętrzna |  | 60 |  |
| Administrator budynku | Służba pomocnicza |  | 15 |  |
| Sekretarka | Administracja |  | 12 |  |
| Prawnik | Firma zewnętrzna |  |  | 150 |
| Firma architektoniczno budowlana | Firma zewnętrzna |  |  | 8000 |
| Pracownik pomocniczy | Pracownicy fizyczni |  | 8 |  |
| Firma transportowa | Firma zewnętrzna |  |  | 5000 |
| Informatyk | Służba pomocnicza |  | 20 |  |
| Elektryk | Pracownicy fizyczni |  | 10 |  |
| Komputer | Sprzęt biurowy |  | 3 |  |
| Sprzątaczka | Służba pomocnicza |  | 6 |  |
| Samochód | Transport |  | 1.25 |  |
| Paliwo | Inne | litr | 3.34 |  |
| Moduł ogłoszeniowy cz-b | Inne | moduł | 180 |  |
| Pojemnik | Sprzęt biurowy | sztuka | 15 |  |

## Schedule

| ID | WBS | Task | Type | Duration | Start | Finish | Predecessors | Total slack | Free slack | Constraint | Deadline |
| --- | --- | --- | --- | --- | --- | --- | --- | --- | --- | --- | --- |
| 1 | 1 | Start | milestone | 0d | 2003-04-01 09:00 | 2003-04-01 09:00 |  | 3.5d | 0d |  |  |
| 2 | 2 | **Poszukiwanie lokalu** |  | 12.5d? | 2003-04-01 09:00 | 2003-04-17 13:00 |  | 0d |  |  |  |
| 3 | 2.1 | Określenie potrzeb |  | 1d | 2003-04-01 09:00 | 2003-04-01 18:00 | 1 | 3.5d | 0d |  |  |
| 4 | 2.2 | Przygotowanie ogłoszenia |  | 0.5d? | 2003-04-02 09:00 | 2003-04-02 13:00 | 3 | 3.5d | 0d | finish no later than 2003-04-07 18:00 |  |
| 5 | 2.3 | Emisja ogłoszenia | milestone | 0d | 2003-04-10 09:00 | 2003-04-10 09:00 | 4 | 0d |  | must start on 2003-04-10 09:00 |  |
| 6 | 2.4 | **Rozpatrywanie ofert** |  | 10.5d? | 2003-04-02 14:00 | 2003-04-16 18:00 |  | 0d |  |  |  |
| 7 | 2.4.1 | **Ocena ofert** |  | 9.5d? | 2003-04-02 14:00 | 2003-04-15 18:00 |  | 0d |  |  |  |
| 8 | 2.4.1.1 | Definiowanie kryteriów oceny |  | 0.5d | 2003-04-02 14:00 | 2003-04-02 18:00 | 4 | 5d |  |  |  |
| 9 | 2.4.1.2 | Wpisywanie zgłoszonych ofert |  | 1d? | 2003-04-10 09:00 | 2003-04-10 18:00 | 5, 8 | 0d |  |  |  |
| 10 | 2.4.1.3 | Wizyty w lokalach |  | 3d? | 2003-04-11 09:00 | 2003-04-15 18:00 | 9 | 0d |  |  |  |
| 11 | 2.4.1.4 | Przypisywanie ocen |  | 1d | 2003-04-15 09:00 | 2003-04-15 18:00 | 10FF | 0d |  |  |  |
| 12 | 2.4.2 | Spisanie i zebranie ocen |  | 1d | 2003-04-16 09:00 | 2003-04-16 18:00 | 11 | 0d |  |  | 2003-05-05 18:00 |
| 13 | 2.5 | Wybór lokalu | milestone | 0d | 2003-04-16 18:00 | 2003-04-16 18:00 | 12 | 0d |  |  |  |
| 14 | 2.6 | Wysyłanie powiadomień o decyzji |  | 0.5d | 2003-04-17 09:00 | 2003-04-17 13:00 | 13 | 0d |  |  |  |
| 15 | 3 | **Przygotowania do przeprowadzki** |  | 26d? | 2003-04-17 14:00 | 2003-05-27 13:00 |  | 0d |  |  |  |
| 16 | 3.1 | Opiniowanie umowy |  | 2d | 2003-04-17 14:00 | 2003-04-22 13:00 | 14 | 0d |  |  |  |
| 17 | 3.2 | Podpisanie umowy |  | 2h | 2003-04-22 14:00 | 2003-04-22 16:00 | 16 | 0d |  |  |  |
| 18 | 3.3 | Wypowiedzenie umowy |  | 1h | 2003-04-22 12:00 | 2003-04-22 14:00 | 17SF | 26.81d |  |  |  |
| 19 | 3.4 | Zdanie lokalu |  | 0.5d? | 2003-05-27 09:00 | 2003-05-27 13:00 | 26 | 2.81d |  |  |  |
| 20 | 3.5 | Ustalenie terminu przeprowadzki |  | 0.5d? | 2003-04-22 16:00 | 2003-04-23 11:00 | 17 | 18.5d | 0d |  |  |
| 21 | 3.6 | Aranżacja wnętrz |  | 1mo | 2003-04-22 16:00 | 2003-05-21 16:00 | 17 | 0d |  |  |  |
| 22 | 4 | **Przeprowadzka** |  | 26.06d | 2003-04-23 11:00 | 2003-05-30 11:30 |  | 0d |  |  |  |
| 23 | 4.1 | Poszukiwanie środka transportu |  | 1d | 2003-04-23 11:00 | 2003-04-24 11:00 | 20 | 18.5d |  |  |  |
| 24 | 4.2 | Odebranie lokalu |  | 1d | 2003-05-21 16:00 | 2003-05-22 16:00 | 21, 23 | 0d |  |  |  |
| 25 | 4.3 | Pakowanie wyposażenia |  | 2d | 2003-05-22 16:00 | 2003-05-26 16:00 | 21, 24 | 0d |  |  |  |
| 26 | 4.4 | Wynoszenie wyposażenia |  | 2h | 2003-05-26 16:00 | 2003-05-26 18:00 | 25 | 0d |  |  |  |
| 27 | 4.5 | Załadunek |  | 1h | 2003-05-26 17:30 | 2003-05-27 09:30 | 26FS-2.5% | 0d |  |  |  |
| 28 | 4.6 | Transport |  | 0.5h | 2003-05-27 09:30 | 2003-05-27 10:00 | 27 | 0d |  |  |  |
| 29 | 4.7 | Wyładunek |  | 1h | 2003-05-27 10:00 | 2003-05-27 11:00 | 28 | 0d |  |  |  |
| 30 | 4.8 | Wnoszenie wyposażenia |  | 2h | 2003-05-27 10:30 | 2003-05-27 12:30 | 29FS-5% | 0d |  |  |  |
| 31 | 4.9 | Rozlokowanie sprzętu |  | 2d | 2003-05-27 11:00 | 2003-05-29 11:00 | 30FS-7.5% | 0.06d |  |  |  |
| 32 | 4.10 | Rozlokowanie wyposażenia |  | 2d | 2003-05-27 11:30 | 2003-05-29 11:30 | 30FS-5% | 0d |  |  |  |
| 33 | 4.11 | Sprzątanie |  | 1d | 2003-05-29 11:30 | 2003-05-30 11:30 | 31, 32 | 0d |  |  |  |
| 34 | 5 | Koniec | milestone | 0d | 2003-05-30 11:30 | 2003-05-30 11:30 | 19, 33 | 0d |  |  |  |

Notes:
- 3: Problematykę tą należy dodatkowo skonsultować z Janem Malinowskim i Krystyną Kowalską. Należy wziąć pod uwagę takie elementy jak: / ·wielkość powierzchni / ·podłączenie do internetu / ·klimatyzację

| ID | WBS | Task | Duration | Start | Finish | Total slack | Constraint |
| --- | --- | --- | --- | --- | --- | --- | --- |
| 35 | 6 | **Przygotowanie raportu** | 38.25d | 2003-04-04 09:00 | 2003-05-30 11:00 | 0.06d |  |
| 36 | 6.1 | Przygotowanie raportu 1 | 2h | 2003-04-04 09:00 | 2003-04-04 11:00 | 38.06d | start no earlier than 2003-04-04 09:00 |
| 37 | 6.2 | Przygotowanie raportu 2 | 2h | 2003-04-11 09:00 | 2003-04-11 11:00 | 33.06d | start no earlier than 2003-04-11 09:00 |
| 38 | 6.3 | Przygotowanie raportu 3 | 2h | 2003-04-18 09:00 | 2003-04-18 11:00 | 28.06d | start no earlier than 2003-04-18 09:00 |
| 39 | 6.4 | Przygotowanie raportu 4 | 2h | 2003-04-25 09:00 | 2003-04-25 11:00 | 24.06d | start no earlier than 2003-04-25 09:00 |
| 40 | 6.5 | Przygotowanie raportu 5 | 2h | 2003-05-02 09:00 | 2003-05-02 11:00 | 20.06d | start no earlier than 2003-05-02 09:00 |
| 41 | 6.6 | Przygotowanie raportu 6 | 2h | 2003-05-09 09:00 | 2003-05-09 11:00 | 15.06d | start no earlier than 2003-05-09 09:00 |
| 42 | 6.7 | Przygotowanie raportu 7 | 2h | 2003-05-16 09:00 | 2003-05-16 11:00 | 10.06d | start no earlier than 2003-05-16 09:00 |
| 43 | 6.8 | Przygotowanie raportu 8 | 2h | 2003-05-23 09:00 | 2003-05-23 11:00 | 5.06d | start no earlier than 2003-05-23 09:00 |
| 44 | 6.9 | Przygotowanie raportu 9 | 2h | 2003-05-30 09:00 | 2003-05-30 11:00 | 0.06d | start no earlier than 2003-05-30 09:00 |
